# Home Construction

Schedule from Primavera P6, 2024-04-29 to 2024-07-31, data date 2024-04-29, costs in USD.

## Calendars

- Calendar 1: Mon 08:00-16:00; Tue-Sat 09:00-14:00, 15:00-19:00; Sun off. Exceptions (off unless hours are given): 2024-05-06, 2024-05-13, 2024-05-20, 2024-05-27.

## Resources

| Resource | Group | Unit | Rate |
| --- | --- | --- | --- |
| Daniel Muller | labor |  | 55 |
| Land Surveyor | labor |  | 65 |
| Excavator | labor |  | 70 |
| Process Operations | labor |  |  |
| Laborer-Construction | labor |  | 18 |
| Ironworker | labor |  | 49 |
| Finish Carpenter | labor |  | 52 |
| Concrete | material | CY | 10 |
| Mason | labor |  | 10 |
| Plumber | labor |  | 58 |
| Finishes & Fit-out Subcontractor | labor |  | 49 |
| Richard Collins | labor |  | 40 |
| Electrician | labor |  | 52 |
| Glass & Glazing Subcontractor | labor |  | 70 |
| Landscaping Subcontractor | labor |  | 72 |

## Schedule

| ID | WBS | Activity | Type | Duration | Start | Finish | Predecessors | Planned start | Planned finish | Total float | Free float | Constraint | Resources | Cost |
| --- | --- | --- | --- | --- | --- | --- | --- | --- | --- | --- | --- | --- | --- | --- |
| A1000 |  | Project Start | milestone | 0d | 2024-04-29 | 2024-04-29 |  |  |  | 76d | 0d |  |  |  |
| A1010 |  | Project Management | level of effort | 63d | 2024-04-29 | 2024-07-08 | A1000 SS |  |  | 22d | 0d |  | Daniel Muller [504 h] | 27,720 |
| A1020 |  | Project Complete | milestone | 0d | 2024-07-08 | 2024-07-08 | A1010 FF, A1170 FF, A1210 FF |  |  | 22d |  |  |  |  |
|  | 1 | **Grading** |  |  | 2024-04-29 | 2024-05-09 |  |  |  |  |  |  |  |  |
| A1030 |  | Survey and mark out site |  | 3d | 2024-04-29 | 2024-05-01 | A1000 SS |  |  | 76d | 0.25d |  | Land Surveyor [24 h] | 1,560 |
| A1040 |  | Site Demarkation |  | 1d | 2024-05-02 | 2024-05-02 | A1030 |  |  | 75.75d | 0d | start on or after 2024-05-02 | Land Surveyor [8 h] | 520 |
| A1050 |  | Excavation | resource dependent | 2.88d | 2024-05-02 | 2024-05-07 | A1040 | 2024-05-03 | 2024-05-07 | 75.75d | 0d | start on or after 2024-05-02 | Excavator [21 h] | 1,470 |
| A1060 |  | Grade Site |  | 0d | 2024-05-07 | 2024-05-09 | A1050 | 2024-05-07 | 2024-05-07 | 75.75d |  | start on or after 2024-05-04 | Process Operations |  |
|  | 2 | **Foundation** |  |  | 2024-04-29 | 2024-05-14 |  |  |  |  |  |  |  |  |
| A1070 |  | Layinh of Foundation |  | 4d | 2024-04-29 | 2024-05-02 |  |  |  | 0d |  |  | Laborer-Construction [32 h]; Ironworker [32 h]; Finish Carpenter [32 h]; Concrete [32 CY]; Mason [32 h] | 4,448 |
| A1080 |  | Slab Plumbing |  | 7d | 2024-05-02 | 2024-05-10 | A1070 |  |  | 0d |  | start on or after 2024-05-02 | Plumber [56 h] | 3,248 |
| A1090 |  | Pour and Float Slab Concrete |  | 2d | 2024-05-10 | 2024-05-14 | A1080 |  |  | 0d |  | start on or after 2024-05-10 | Concrete [16 CY] | 160 |
|  | 3 | **Structure** |  |  | 2024-04-29 | 2024-07-31 |  |  |  |  |  |  |  |  |
|  | 1 | **Framing** |  |  | 2024-05-14 | 2024-07-08 |  |  |  |  |  |  |  |  |
| A1100 |  | Exterior Walls |  | 20d | 2024-05-14 | 2024-06-06 | A1090 |  |  | 0d |  | start on or after 2024-05-11 | Mason [160 h]; Finishes & Fit-out Subcontractor [160 h] | 1,600 |
| A1110 |  | Interior Walls |  | 25d | 2024-06-06 | 2024-07-03 | A1100 |  |  | 21d | 0d | start on or after 2024-06-04 | Mason [200 h]; Finishes & Fit-out Subcontractor [200 h] | 2,000 |
| A1120 |  | Exterior Cladding |  | 30d | 2024-06-06 | 2024-07-08 | A1100 |  |  | 0d |  | start on or after 2024-06-04 | Mason [240 h]; Finishes & Fit-out Subcontractor [240 h] | 2,400 |
|  | 2 | **Roof** |  |  | 2024-06-06 | 2024-07-05 |  |  |  |  |  |  |  |  |
| A1130 |  | Truss Placing |  | 15d | 2024-06-06 | 2024-06-22 | A1110 SS, A1100 |  |  | 21d | 0d | start on or after 2024-06-04 | Ironworker [120 h] | 5,880 |
| A1140 |  | Roof Sheeting |  | 10d | 2024-06-22 | 2024-07-03 | A1130 |  |  | 21d | 0d | start on or after 2024-06-19 | Laborer-Construction [80 h] | 1,440 |
| A1150 |  | Place Paper and Shingles |  | 3d | 2024-07-03 | 2024-07-05 | A1140 |  |  | 21d | 0d | start on or after 2024-06-28 | Laborer-Construction [24 h] | 432 |
|  | 3 | **Interior** |  |  | 2024-04-29 | 2024-07-09 |  |  |  |  |  |  |  |  |
|  | 1 | **Mechanical** |  |  | 2024-07-05 | 2024-07-09 |  |  |  |  |  |  |  |  |
| A1160 |  | HVAC Ducting |  | 3d | 2024-07-05 | 2024-07-09 | A1150 |  |  | 21d | 0d | start on or after 2024-07-01 | Richard Collins [24 h] | 960 |
| A1170 |  | Install HVAC Unit |  | 2d | 2024-07-05 | 2024-07-08 | A1160 SS |  |  | 22d | 0d | start on or after 2024-07-04 | Richard Collins [16 h] | 640 |

| ID | WBS | Activity | Duration | Start | Finish | Predecessors | Total float | Free float | Constraint | Resources | Cost |
| --- | --- | --- | --- | --- | --- | --- | --- | --- | --- | --- | --- |
|  | 2 | **Electrical** |  | 2024-06-06 | 2024-06-19 |  |  |  |  |  |  |
| A1180 |  | Breaker Box and Rough Wire | 5d | 2024-06-06 | 2024-06-12 | A1110 SS, A1100 | 40d | 0d | start on or after 2024-06-04 | Electrician [40 h] | 2,080 |
| A1190 |  | Finish Wiring | 7d | 2024-06-12 | 2024-06-19 | A1180 | 40d |  | start on or after 2024-06-08 | Electrician [56 h] | 2,912 |
|  | 3 | **Plumbing** |  | 2024-06-06 | 2024-06-17 |  |  |  |  |  |  |
| A1200 |  | Install Rough Plumbing Lines | 10d | 2024-06-06 | 2024-06-17 | A1110 SS, A1100 | 28d | 0d | start on or after 2024-06-04 | Plumber [80 h] | 4,640 |
|  | 4 | **Decor** |  | 2024-04-29 | 2024-07-02 |  |  |  |  |  |  |
| A1210 |  | Kitchen Cabinet | 10d | 2024-04-29 | 2024-05-09 |  | 75d | 53d |  | Finish Carpenter [80 h] | 4,160 |
| A1220 |  | Placing Doors | 8d | 2024-06-17 | 2024-06-25 | A1200 | 28d | 0d | start on or after 2024-06-13 | Finish Carpenter [64 h] | 3,328 |
| A1230 |  | Door Placing and Baseboards | 6d | 2024-06-25 | 2024-07-02 | A1220 | 28d |  | start on or after 2024-06-21 | Finish Carpenter [48 h] | 2,496 |
|  | 4 | **Exterior** |  | 2024-07-08 | 2024-07-26 |  |  |  |  |  |  |
| A1240 |  | Place Windows | 12d | 2024-07-08 | 2024-07-20 | A1120 | 0d |  | start on or after 2024-07-05 | Glass & Glazing Subcontractor [96 h]; Finish Carpenter [96 h] | 4,992 |
| A1250 |  | Window Sidings | 5d | 2024-07-20 | 2024-07-26 | A1240 | 0d |  | start on or after 2024-07-17 | Finish Carpenter [40 h] | 2,080 |
|  | 5 | **Landscaping** |  | 2024-07-26 | 2024-07-31 |  |  |  |  |  |  |
| A1260 |  | Tree Planting | 5d | 2024-07-26 | 2024-07-31 | A1250 | 0d |  | start on or after 2024-07-22 | Landscaping Subcontractor [40 h] |  |

## Risks

| ID | Risk | Status |
| --- | --- | --- |
| RISK1 | Non availability of masonry crew | RS_Propose |
| RISK2 | Non availability of roof sheeting manpower | RS_Propose |

## Issues

| Issue | Status | Raised |
| --- | --- | --- |
| Start Date Variance (days) is 0 on WBS: CD00720 | IS_Open | 2024-04-29 |
| Start Date Variance (days) is 0 on WBS: CD00720.1 | IS_Open | 2024-04-29 |
| Start Date Variance (days) is 0 on WBS: CD00720.2 | IS_Open | 2024-04-29 |
| Start Date Variance (days) is 0 on WBS: CD00720.3 | IS_Open | 2024-04-29 |
| Start Date Variance (days) is 0 on WBS: CD00720.3.1 | IS_Open | 2024-04-29 |
| Start Date Variance (days) is 0 on WBS: CD00720.3.2 | IS_Open | 2024-04-29 |
| Start Date Variance (days) is 0 on WBS: CD00720.3.3 | IS_Open | 2024-04-29 |
| Start Date Variance (days) is 0 on WBS: CD00720.3.3.1 | IS_Open | 2024-04-29 |
| Start Date Variance (days) is 0 on WBS: CD00720.3.3.2 | IS_Open | 2024-04-29 |
| Start Date Variance (days) is 0 on WBS: CD00720.3.3.3 | IS_Open | 2024-04-29 |
| Start Date Variance (days) is 0 on WBS: CD00720.3.3.4 | IS_Open | 2024-04-29 |
| Start Date Variance (days) is 0 on WBS: CD00720.3.4 | IS_Open | 2024-04-29 |
| Start Date Variance (days) is 0 on WBS: CD00720.3.5 | IS_Open | 2024-04-29 |
